# 210311 CRONOGRAMA GYM REV2

Schedule from MS Project, 2011-01-17 to 2012-04-27.
GyM

## Calendars

- Estándar: Mon-Fri 09:00-13:00, 15:00-19:00; Sat-Sun off.

## Schedule

| ID | WBS | Task | Type | Duration | Start | Finish | Predecessors | Total slack | Free slack | Constraint |
| --- | --- | --- | --- | --- | --- | --- | --- | --- | --- | --- |
| 1 | 1 | **EDIFICIO DE VIVIENDAS NEO 10** |  | 335d | 2011-01-17 | 2012-04-27 |  | 0d |  |  |
| 2 | 1.1 | Inicio | milestone | 0d | 2011-01-17 | 2011-01-17 |  | 26d | 0d |  |
| 3 | 1.2 | **OBRAS PRELMINARES** |  | 18d | 2011-01-17 | 2011-02-09 |  | 26d |  |  |
| 4 | 1.2.1 | Movilización |  | 10d | 2011-01-17 | 2011-01-28 | 2 | 26d | 0d |  |
| 5 | 1.2.2 | Obras Provisionales |  | 15d | 2011-01-20 | 2011-02-09 | 4FS-7d | 26d | 0d |  |
| 6 | 1.3 | **MOVIMIENTO DE TIERRAS Y ESTABILIZACIÓN** |  | 73d | 2011-01-27 | 2011-05-09 |  | 20d | 254d |  |
| 7 | 1.3.1 | **Sotano 1** |  | 25d | 2011-01-27 | 2011-03-02 |  | 26d |  |  |
| 8 | 1.3.1.1 | Excavación y eliminación |  | 15d | 2011-01-27 | 2011-02-16 | 5SS+5d | 26d | 0d |  |
| 9 | 1.3.1.2 | Perforación e inyección |  | 13d | 2011-02-03 | 2011-02-21 | 8SS+5d | 26d | 0d |  |
| 10 | 1.3.1.3 | Perfilado |  | 13d | 2011-02-04 | 2011-02-22 | 9SS+1d | 26d | 0d |  |
| 11 | 1.3.1.4 | Acero |  | 13d | 2011-02-07 | 2011-02-23 | 10SS+1d | 26d | 0d |  |
| 12 | 1.3.1.5 | Encofrado |  | 13d | 2011-02-08 | 2011-02-24 | 11SS+1d | 26d | 0d |  |
| 13 | 1.3.1.6 | Concreto |  | 13d | 2011-02-09 | 2011-02-25 | 12SS+1d | 26d | 0d |  |
| 14 | 1.3.1.7 | Tensado |  | 13d | 2011-02-14 | 2011-03-02 | 13SS+3d | 26d | 0d |  |
| 15 | 1.3.2 | **Sotano 2** |  | 21d | 2011-02-24 | 2011-03-24 |  | 26d |  |  |
| 16 | 1.3.2.1 | Excavación y eliminación |  | 13d | 2011-02-24 | 2011-03-14 | 14FS-5d | 26d | 0d |  |
| 17 | 1.3.2.2 | Perforación e inyección |  | 13d | 2011-02-25 | 2011-03-15 | 16SS+1d | 26d | 0d |  |
| 18 | 1.3.2.3 | Perfilado |  | 13d | 2011-02-28 | 2011-03-16 | 17SS+1d | 26d | 0d |  |
| 19 | 1.3.2.4 | Acero |  | 13d | 2011-03-01 | 2011-03-17 | 18SS+1d | 26d | 0d |  |
| 20 | 1.3.2.5 | Encofrado |  | 13d | 2011-03-02 | 2011-03-18 | 19SS+1d | 26d | 0d |  |
| 21 | 1.3.2.6 | Concreto |  | 13d | 2011-03-03 | 2011-03-21 | 20SS+1d | 26d | 0d |  |
| 22 | 1.3.2.7 | Tensado |  | 13d | 2011-03-08 | 2011-03-24 | 21SS+3d | 26d | 6d |  |
| 23 | 1.3.3 | **Sotano 3** |  | 18d | 2011-03-30 | 2011-04-22 |  | 20d |  |  |
| 24 | 1.3.3.1 | Excavación y eliminación |  | 10d | 2011-03-30 | 2011-04-12 | 22FS-3d | 20d | 0d | start no earlier than 2011-03-30 |
| 25 | 1.3.3.2 | Perforación e inyección |  | 10d | 2011-03-31 | 2011-04-13 | 24SS+1d | 20d | 0d |  |
| 26 | 1.3.3.3 | Perfilado |  | 10d | 2011-04-01 | 2011-04-14 | 25SS+1d | 20d | 0d |  |
| 27 | 1.3.3.4 | Acero |  | 10d | 2011-04-04 | 2011-04-15 | 26SS+1d | 20d | 0d |  |
| 28 | 1.3.3.5 | Encofrado |  | 10d | 2011-04-05 | 2011-04-18 | 27SS+1d | 20d | 0d |  |
| 29 | 1.3.3.6 | Concreto |  | 10d | 2011-04-06 | 2011-04-19 | 28SS+1d | 20d | 0d |  |
| 30 | 1.3.3.7 | Tensado |  | 10d | 2011-04-11 | 2011-04-22 | 29SS+3d | 20d | 0d |  |

| ID | WBS | Task | Duration | Start | Finish | Predecessors | Total slack | Free slack |
| --- | --- | --- | --- | --- | --- | --- | --- | --- |
| 31 | 1.3.4 | **Sotano 4** | 14d | 2011-04-20 | 2011-05-09 |  | 20d |  |
| 32 | 1.3.4.1 | Excavación y eliminación | 10d | 2011-04-20 | 2011-05-03 | 30FS-3d | 20d | 0d |
| 33 | 1.3.4.2 | Perfilado | 10d | 2011-04-21 | 2011-05-04 | 32SS+1d | 20d | 0d |
| 34 | 1.3.4.3 | Acero | 10d | 2011-04-22 | 2011-05-05 | 33SS+1d | 20d | 0d |
| 35 | 1.3.4.4 | Encofrado | 10d | 2011-04-25 | 2011-05-06 | 34SS+1d | 20d | 0d |
| 36 | 1.3.4.5 | Concreto | 10d | 2011-04-26 | 2011-05-09 | 35SS+1d | 20d | 0d |
| 37 | 1.4 | **ESTRUCTURAS** | 111d | 2011-04-29 | 2011-09-30 |  | 20d | 150d |
| 38 | 1.4.1 | **Sotanos** | 40d | 2011-04-29 | 2011-06-23 |  | 20d |  |
| 39 | 1.4.1.1 | **Cimentación** | 21d | 2011-04-29 | 2011-05-27 |  | 20d |  |
| 40 | 1.4.1.1.1 | Excavación | 18d | 2011-04-29 | 2011-05-24 | 36FS-7d | 20d | 0d |
| 41 | 1.4.1.1.2 | Acero | 18d | 2011-05-02 | 2011-05-25 | 40SS+1d | 20d | 0d |
| 42 | 1.4.1.1.3 | Encofrado | 18d | 2011-05-03 | 2011-05-26 | 41SS+1d | 240d | 0d |
| 43 | 1.4.1.1.4 | Concreto | 18d | 2011-05-04 | 2011-05-27 | 42SS+1d | 240d |  |
| 44 | 1.4.1.2 | **Sotano 4** | 9d | 2011-05-23 | 2011-06-02 |  | 20d | 0d |
| 45 | 1.4.1.2.1 | **Verticales** | 6d | 2011-05-23 | 2011-05-30 |  | 20d |  |
| 46 | 1.4.1.2.1.1 | Acero | 5d | 2011-05-23 | 2011-05-27 | 41SS+15d | 20d | 0d |
| 47 | 1.4.1.2.1.2 | Encofrado | 5d | 2011-05-24 | 2011-05-30 | 46SS+1d | 236d | 0d |
| 48 | 1.4.1.2.1.3 | Concreto | 5d | 2011-05-24 | 2011-05-30 | 47SS | 236d | 0d |
| 49 | 1.4.1.2.2 | **Horizontales** | 7d | 2011-05-25 | 2011-06-02 |  | 236d |  |
| 50 | 1.4.1.2.2.1 | Encofrado de vigas | 5d | 2011-05-25 | 2011-05-31 | 48SS+1d | 236d | 0d |
| 51 | 1.4.1.2.2.2 | Encofrado de losas | 5d | 2011-05-26 | 2011-06-01 | 50SS+1d | 236d | 0d |
| 52 | 1.4.1.2.2.3 | Acero de vigas y losas | 5d | 2011-05-27 | 2011-06-02 | 51SS+1d | 236d | 0d |
| 53 | 1.4.1.2.2.4 | Concreto | 5d | 2011-05-27 | 2011-06-02 | 52SS | 236d |  |
| 54 | 1.4.1.3 | **Sotano 3** | 9d | 2011-05-30 | 2011-06-09 |  | 20d |  |
| 55 | 1.4.1.3.1 | **Verticales** | 6d | 2011-05-30 | 2011-06-06 |  | 20d |  |
| 56 | 1.4.1.3.1.1 | Acero | 5d | 2011-05-30 | 2011-06-03 | 46 | 20d | 0d |
| 57 | 1.4.1.3.1.2 | Encofrado | 5d | 2011-05-31 | 2011-06-06 | 56SS+1d | 231d | 0d |
| 58 | 1.4.1.3.1.3 | Concreto | 5d | 2011-05-31 | 2011-06-06 | 57SS | 231d | 0d |

| ID | WBS | Task | Duration | Start | Finish | Predecessors | Total slack | Free slack |
| --- | --- | --- | --- | --- | --- | --- | --- | --- |
| 59 | 1.4.1.3.2 | **Horizontales** | 7d | 2011-06-01 | 2011-06-09 |  | 231d |  |
| 60 | 1.4.1.3.2.1 | Encofrado de vigas | 5d | 2011-06-01 | 2011-06-07 | 58SS+1d | 231d | 0d |
| 61 | 1.4.1.3.2.2 | Encofrado de losas | 5d | 2011-06-02 | 2011-06-08 | 60SS+1d | 231d | 0d |
| 62 | 1.4.1.3.2.3 | Acero de vigas y losas | 5d | 2011-06-03 | 2011-06-09 | 61SS+1d | 231d | 0d |
| 63 | 1.4.1.3.2.4 | Concreto | 5d | 2011-06-03 | 2011-06-09 | 62SS | 231d |  |
| 64 | 1.4.1.4 | **Sotano 2** | 9d | 2011-06-06 | 2011-06-16 |  | 20d |  |
| 65 | 1.4.1.4.1 | **Verticales** | 6d | 2011-06-06 | 2011-06-13 |  | 20d |  |
| 66 | 1.4.1.4.1.1 | Acero | 5d | 2011-06-06 | 2011-06-10 | 56 | 20d | 0d |
| 67 | 1.4.1.4.1.2 | Encofrado | 5d | 2011-06-07 | 2011-06-13 | 66SS+1d | 226d | 0d |
| 68 | 1.4.1.4.1.3 | Concreto | 5d | 2011-06-07 | 2011-06-13 | 67SS | 226d | 0d |
| 69 | 1.4.1.4.2 | **Horizontales** | 7d | 2011-06-08 | 2011-06-16 |  | 226d |  |
| 70 | 1.4.1.4.2.1 | Encofrado de vigas | 5d | 2011-06-08 | 2011-06-14 | 68SS+1d | 226d | 0d |
| 71 | 1.4.1.4.2.2 | Encofrado de losas | 5d | 2011-06-09 | 2011-06-15 | 70SS+1d | 226d | 0d |
| 72 | 1.4.1.4.2.3 | Acero de vigas y losas | 5d | 2011-06-10 | 2011-06-16 | 71SS+1d | 226d | 0d |
| 73 | 1.4.1.4.2.4 | Concreto | 5d | 2011-06-10 | 2011-06-16 | 72SS | 226d |  |
| 74 | 1.4.1.5 | **Sotano 1** | 9d | 2011-06-13 | 2011-06-23 |  | 20d | 0d |
| 75 | 1.4.1.5.1 | **Verticales** | 6d | 2011-06-13 | 2011-06-20 |  | 20d |  |
| 76 | 1.4.1.5.1.1 | Acero | 5d | 2011-06-13 | 2011-06-17 | 66 | 20d | 0d |
| 77 | 1.4.1.5.1.2 | Encofrado | 5d | 2011-06-14 | 2011-06-20 | 76SS+1d | 193d | 0d |
| 78 | 1.4.1.5.1.3 | Concreto | 5d | 2011-06-14 | 2011-06-20 | 77SS | 193d | 0d |
| 79 | 1.4.1.5.2 | **Horizontales** | 7d | 2011-06-15 | 2011-06-23 |  | 193d |  |
| 80 | 1.4.1.5.2.1 | Encofrado de vigas | 5d | 2011-06-15 | 2011-06-21 | 78SS+1d | 193d | 0d |
| 81 | 1.4.1.5.2.2 | Encofrado de losas | 5d | 2011-06-16 | 2011-06-22 | 80SS+1d | 193d | 0d |
| 82 | 1.4.1.5.2.3 | Acero de vigas y losas | 5d | 2011-06-17 | 2011-06-23 | 81SS+1d | 193d | 0d |
| 83 | 1.4.1.5.2.4 | Concreto | 5d | 2011-06-17 | 2011-06-23 | 82SS | 193d |  |

| ID | WBS | Task | Duration | Start | Finish | Predecessors | Total slack | Free slack |
| --- | --- | --- | --- | --- | --- | --- | --- | --- |
| 84 | 1.4.2 | **Torre** | 75d | 2011-06-20 | 2011-09-30 |  | 20d |  |
| 85 | 1.4.2.1 | **Piso 1** | 7d | 2011-06-20 | 2011-06-28 |  | 20d | 0d |
| 86 | 1.4.2.1.1 | **Verticales** | 5d | 2011-06-20 | 2011-06-24 |  | 20d |  |
| 87 | 1.4.2.1.1.1 | Acero | 4d | 2011-06-20 | 2011-06-23 | 76 | 20d | 0d |
| 88 | 1.4.2.1.1.2 | Encofrado | 4d | 2011-06-21 | 2011-06-24 | 87SS+1d | 190d | 0d |
| 89 | 1.4.2.1.1.3 | Concreto | 4d | 2011-06-21 | 2011-06-24 | 88SS | 190d | 0d |
| 90 | 1.4.2.1.2 | **Horizontales** | 5d | 2011-06-22 | 2011-06-28 |  | 190d |  |
| 91 | 1.4.2.1.2.1 | Encofrado de vigas | 4d | 2011-06-22 | 2011-06-27 | 89SS+1d | 190d | 0d |
| 92 | 1.4.2.1.2.2 | Encofrado de losas | 4d | 2011-06-22 | 2011-06-27 | 91SS | 190d | 0d |
| 93 | 1.4.2.1.2.3 | Acero de vigas y losas | 4d | 2011-06-23 | 2011-06-28 | 92SS+1d | 190d | 0d |
| 94 | 1.4.2.1.2.4 | Concreto | 4d | 2011-06-23 | 2011-06-28 | 93SS | 190d |  |
| 95 | 1.4.2.2 | **Piso 2** | 7d | 2011-06-24 | 2011-07-04 |  | 20d | 0d |
| 96 | 1.4.2.2.1 | **Verticales** | 5d | 2011-06-24 | 2011-06-30 |  | 20d |  |
| 97 | 1.4.2.2.1.1 | Acero | 4d | 2011-06-24 | 2011-06-29 | 87 | 20d | 0d |
| 98 | 1.4.2.2.1.2 | Encofrado | 4d | 2011-06-27 | 2011-06-30 | 97SS+1d | 20d | 0d |
| 99 | 1.4.2.2.1.3 | Concreto | 4d | 2011-06-27 | 2011-06-30 | 98SS | 20d | 0d |
| 100 | 1.4.2.2.2 | **Horizontales** | 5d | 2011-06-28 | 2011-07-04 |  | 20d |  |
| 101 | 1.4.2.2.2.1 | Encofrado de vigas | 4d | 2011-06-28 | 2011-07-01 | 99SS+1d | 20d | 0d |
| 102 | 1.4.2.2.2.2 | Encofrado de losas | 4d | 2011-06-28 | 2011-07-01 | 101SS | 20d | 0d |
| 103 | 1.4.2.2.2.3 | Acero de vigas y losas | 4d | 2011-06-29 | 2011-07-04 | 102SS+1d | 20d | 0d |
| 104 | 1.4.2.2.2.4 | Concreto | 4d | 2011-06-29 | 2011-07-04 | 103SS | 20d |  |
| 105 | 1.4.2.3 | **Piso 3** | 7d | 2011-06-30 | 2011-07-08 |  | 102d | 0d |
| 106 | 1.4.2.3.1 | **Verticales** | 5d | 2011-06-30 | 2011-07-06 |  | 102d |  |
| 107 | 1.4.2.3.1.1 | Acero | 4d | 2011-06-30 | 2011-07-05 | 97 | 102d | 0d |
| 108 | 1.4.2.3.1.2 | Encofrado | 4d | 2011-07-01 | 2011-07-06 | 107SS+1d | 182d | 0d |
| 109 | 1.4.2.3.1.3 | Concreto | 4d | 2011-07-01 | 2011-07-06 | 108SS | 182d | 0d |

| ID | WBS | Task | Duration | Start | Finish | Predecessors | Total slack | Free slack |
| --- | --- | --- | --- | --- | --- | --- | --- | --- |
| 110 | 1.4.2.3.2 | **Horizontales** | 5d | 2011-07-04 | 2011-07-08 |  | 182d |  |
| 111 | 1.4.2.3.2.1 | Encofrado de vigas | 4d | 2011-07-04 | 2011-07-07 | 109SS+1d | 182d | 0d |
| 112 | 1.4.2.3.2.2 | Encofrado de losas | 4d | 2011-07-04 | 2011-07-07 | 111SS | 182d | 0d |
| 113 | 1.4.2.3.2.3 | Acero de vigas y losas | 4d | 2011-07-05 | 2011-07-08 | 112SS+1d | 182d | 0d |
| 114 | 1.4.2.3.2.4 | Concreto | 4d | 2011-07-05 | 2011-07-08 | 113SS | 182d |  |
| 115 | 1.4.2.4 | **Piso 4** | 7d | 2011-07-06 | 2011-07-14 |  | 102d | 0d |
| 116 | 1.4.2.4.1 | **Verticales** | 5d | 2011-07-06 | 2011-07-12 |  | 102d |  |
| 117 | 1.4.2.4.1.1 | Acero | 4d | 2011-07-06 | 2011-07-11 | 107 | 102d | 0d |
| 118 | 1.4.2.4.1.2 | Encofrado | 4d | 2011-07-07 | 2011-07-12 | 117SS+1d | 173d | 0d |
| 119 | 1.4.2.4.1.3 | Concreto | 4d | 2011-07-07 | 2011-07-12 | 118SS | 173d | 0d |
| 120 | 1.4.2.4.2 | **Horizontales** | 5d | 2011-07-08 | 2011-07-14 |  | 173d |  |
| 121 | 1.4.2.4.2.1 | Encofrado de vigas | 4d | 2011-07-08 | 2011-07-13 | 119SS+1d | 173d | 0d |
| 122 | 1.4.2.4.2.2 | Encofrado de losas | 4d | 2011-07-08 | 2011-07-13 | 121SS | 173d | 0d |
| 123 | 1.4.2.4.2.3 | Acero de vigas y losas | 4d | 2011-07-11 | 2011-07-14 | 122SS+1d | 173d | 0d |
| 124 | 1.4.2.4.2.4 | Concreto | 4d | 2011-07-11 | 2011-07-14 | 123SS | 173d |  |
| 125 | 1.4.2.5 | **Piso 5** | 7d | 2011-07-12 | 2011-07-20 |  | 102d | 0d |
| 126 | 1.4.2.5.1 | **Verticales** | 5d | 2011-07-12 | 2011-07-18 |  | 102d |  |
| 127 | 1.4.2.5.1.1 | Acero | 4d | 2011-07-12 | 2011-07-15 | 117 | 102d | 0d |
| 128 | 1.4.2.5.1.2 | Encofrado | 4d | 2011-07-13 | 2011-07-18 | 127SS+1d | 169d | 0d |
| 129 | 1.4.2.5.1.3 | Concreto | 4d | 2011-07-13 | 2011-07-18 | 128SS | 169d | 0d |
| 130 | 1.4.2.5.2 | **Horizontales** | 5d | 2011-07-14 | 2011-07-20 |  | 169d |  |
| 131 | 1.4.2.5.2.1 | Encofrado de vigas | 4d | 2011-07-14 | 2011-07-19 | 129SS+1d | 169d | 0d |
| 132 | 1.4.2.5.2.2 | Encofrado de losas | 4d | 2011-07-14 | 2011-07-19 | 131SS | 169d | 0d |
| 133 | 1.4.2.5.2.3 | Acero de vigas y losas | 4d | 2011-07-15 | 2011-07-20 | 132SS+1d | 169d | 0d |
| 134 | 1.4.2.5.2.4 | Concreto | 4d | 2011-07-15 | 2011-07-20 | 133SS | 169d |  |

| ID | WBS | Task | Duration | Start | Finish | Predecessors | Total slack | Free slack |
| --- | --- | --- | --- | --- | --- | --- | --- | --- |
| 135 | 1.4.2.6 | **Piso 6** | 7d | 2011-07-18 | 2011-07-26 |  | 102d | 0d |
| 136 | 1.4.2.6.1 | **Verticales** | 5d | 2011-07-18 | 2011-07-22 |  | 102d |  |
| 137 | 1.4.2.6.1.1 | Acero | 4d | 2011-07-18 | 2011-07-21 | 127 | 102d | 0d |
| 138 | 1.4.2.6.1.2 | Encofrado | 4d | 2011-07-19 | 2011-07-22 | 137SS+1d | 165d | 0d |
| 139 | 1.4.2.6.1.3 | Concreto | 4d | 2011-07-19 | 2011-07-22 | 138SS | 165d | 0d |
| 140 | 1.4.2.6.2 | **Horizontales** | 5d | 2011-07-20 | 2011-07-26 |  | 165d |  |
| 141 | 1.4.2.6.2.1 | Encofrado de vigas | 4d | 2011-07-20 | 2011-07-25 | 139SS+1d | 165d | 0d |
| 142 | 1.4.2.6.2.2 | Encofrado de losas | 4d | 2011-07-20 | 2011-07-25 | 141SS | 165d | 0d |
| 143 | 1.4.2.6.2.3 | Acero de vigas y losas | 4d | 2011-07-21 | 2011-07-26 | 142SS+1d | 165d | 0d |
| 144 | 1.4.2.6.2.4 | Concreto | 4d | 2011-07-21 | 2011-07-26 | 143SS | 165d |  |
| 145 | 1.4.2.7 | **Piso 7** | 7d | 2011-07-22 | 2011-08-01 |  | 102d | 0d |
| 146 | 1.4.2.7.1 | **Verticales** | 5d | 2011-07-22 | 2011-07-28 |  | 102d |  |
| 147 | 1.4.2.7.1.1 | Acero | 4d | 2011-07-22 | 2011-07-27 | 137 | 102d | 0d |
| 148 | 1.4.2.7.1.2 | Encofrado | 4d | 2011-07-25 | 2011-07-28 | 147SS+1d | 161d | 0d |
| 149 | 1.4.2.7.1.3 | Concreto | 4d | 2011-07-25 | 2011-07-28 | 148SS | 161d | 0d |
| 150 | 1.4.2.7.2 | **Horizontales** | 5d | 2011-07-26 | 2011-08-01 |  | 161d |  |
| 151 | 1.4.2.7.2.1 | Encofrado de vigas | 4d | 2011-07-26 | 2011-07-29 | 149SS+1d | 161d | 0d |
| 152 | 1.4.2.7.2.2 | Encofrado de losas | 4d | 2011-07-26 | 2011-07-29 | 151SS | 161d | 0d |
| 153 | 1.4.2.7.2.3 | Acero de vigas y losas | 4d | 2011-07-27 | 2011-08-01 | 152SS+1d | 161d | 0d |
| 154 | 1.4.2.7.2.4 | Concreto | 4d | 2011-07-27 | 2011-08-01 | 153SS | 161d |  |
| 155 | 1.4.2.8 | **Piso 8** | 7d | 2011-07-28 | 2011-08-05 |  | 102d | 0d |
| 156 | 1.4.2.8.1 | **Verticales** | 5d | 2011-07-28 | 2011-08-03 |  | 102d |  |
| 157 | 1.4.2.8.1.1 | Acero | 4d | 2011-07-28 | 2011-08-02 | 147 | 102d | 0d |
| 158 | 1.4.2.8.1.2 | Encofrado | 4d | 2011-07-29 | 2011-08-03 | 157SS+1d | 157d | 0d |
| 159 | 1.4.2.8.1.3 | Concreto | 4d | 2011-07-29 | 2011-08-03 | 158SS | 157d | 0d |

| ID | WBS | Task | Duration | Start | Finish | Predecessors | Total slack | Free slack |
| --- | --- | --- | --- | --- | --- | --- | --- | --- |
| 160 | 1.4.2.8.2 | **Horizontales** | 5d | 2011-08-01 | 2011-08-05 |  | 157d |  |
| 161 | 1.4.2.8.2.1 | Encofrado de vigas | 4d | 2011-08-01 | 2011-08-04 | 159SS+1d | 157d | 0d |
| 162 | 1.4.2.8.2.2 | Encofrado de losas | 4d | 2011-08-01 | 2011-08-04 | 161SS | 157d | 0d |
| 163 | 1.4.2.8.2.3 | Acero de vigas y losas | 4d | 2011-08-02 | 2011-08-05 | 162SS+1d | 157d | 0d |
| 164 | 1.4.2.8.2.4 | Concreto | 4d | 2011-08-02 | 2011-08-05 | 163SS | 157d |  |
| 165 | 1.4.2.9 | **Piso 9** | 7d | 2011-08-03 | 2011-08-11 |  | 102d | 0d |
| 166 | 1.4.2.9.1 | **Verticales** | 5d | 2011-08-03 | 2011-08-09 |  | 102d |  |
| 167 | 1.4.2.9.1.1 | Acero | 4d | 2011-08-03 | 2011-08-08 | 157 | 102d | 0d |
| 168 | 1.4.2.9.1.2 | Encofrado | 4d | 2011-08-04 | 2011-08-09 | 167SS+1d | 153d | 0d |
| 169 | 1.4.2.9.1.3 | Concreto | 4d | 2011-08-04 | 2011-08-09 | 168SS | 153d | 0d |
| 170 | 1.4.2.9.2 | **Horizontales** | 5d | 2011-08-05 | 2011-08-11 |  | 153d |  |
| 171 | 1.4.2.9.2.1 | Encofrado de vigas | 4d | 2011-08-05 | 2011-08-10 | 169SS+1d | 153d | 0d |
| 172 | 1.4.2.9.2.2 | Encofrado de losas | 4d | 2011-08-05 | 2011-08-10 | 171SS | 153d | 0d |
| 173 | 1.4.2.9.2.3 | Acero de vigas y losas | 4d | 2011-08-08 | 2011-08-11 | 172SS+1d | 153d | 0d |
| 174 | 1.4.2.9.2.4 | Concreto | 4d | 2011-08-08 | 2011-08-11 | 173SS | 153d |  |
| 175 | 1.4.2.10 | **Piso 10** | 7d | 2011-08-09 | 2011-08-17 |  | 102d | 0d |
| 176 | 1.4.2.10.1 | **Verticales** | 5d | 2011-08-09 | 2011-08-15 |  | 102d |  |
| 177 | 1.4.2.10.1.1 | Acero | 4d | 2011-08-09 | 2011-08-12 | 167 | 102d | 0d |
| 178 | 1.4.2.10.1.2 | Encofrado | 4d | 2011-08-10 | 2011-08-15 | 177SS+1d | 149d | 0d |
| 179 | 1.4.2.10.1.3 | Concreto | 4d | 2011-08-10 | 2011-08-15 | 178SS | 149d | 0d |
| 180 | 1.4.2.10.2 | **Horizontales** | 5d | 2011-08-11 | 2011-08-17 |  | 149d |  |
| 181 | 1.4.2.10.2.1 | Encofrado de vigas | 4d | 2011-08-11 | 2011-08-16 | 179SS+1d | 149d | 0d |
| 182 | 1.4.2.10.2.2 | Encofrado de losas | 4d | 2011-08-11 | 2011-08-16 | 181SS | 149d | 0d |
| 183 | 1.4.2.10.2.3 | Acero de vigas y losas | 4d | 2011-08-12 | 2011-08-17 | 182SS+1d | 149d | 0d |
| 184 | 1.4.2.10.2.4 | Concreto | 4d | 2011-08-12 | 2011-08-17 | 183SS | 149d |  |

| ID | WBS | Task | Duration | Start | Finish | Predecessors | Total slack | Free slack |
| --- | --- | --- | --- | --- | --- | --- | --- | --- |
| 185 | 1.4.2.11 | **Piso 11** | 7d | 2011-08-15 | 2011-08-23 |  | 102d | 0d |
| 186 | 1.4.2.11.1 | **Verticales** | 5d | 2011-08-15 | 2011-08-19 |  | 102d |  |
| 187 | 1.4.2.11.1.1 | Acero | 4d | 2011-08-15 | 2011-08-18 | 177 | 102d | 0d |
| 188 | 1.4.2.11.1.2 | Encofrado | 4d | 2011-08-16 | 2011-08-19 | 187SS+1d | 145d | 0d |
| 189 | 1.4.2.11.1.3 | Concreto | 4d | 2011-08-16 | 2011-08-19 | 188SS | 145d | 0d |
| 190 | 1.4.2.11.2 | **Horizontales** | 5d | 2011-08-17 | 2011-08-23 |  | 145d |  |
| 191 | 1.4.2.11.2.1 | Encofrado de vigas | 4d | 2011-08-17 | 2011-08-22 | 189SS+1d | 145d | 0d |
| 192 | 1.4.2.11.2.2 | Encofrado de losas | 4d | 2011-08-17 | 2011-08-22 | 191SS | 145d | 0d |
| 193 | 1.4.2.11.2.3 | Acero de vigas y losas | 4d | 2011-08-18 | 2011-08-23 | 192SS+1d | 145d | 0d |
| 194 | 1.4.2.11.2.4 | Concreto | 4d | 2011-08-18 | 2011-08-23 | 193SS | 145d |  |
| 195 | 1.4.2.12 | **Piso 12** | 7d | 2011-08-19 | 2011-08-29 |  | 102d | 0d |
| 196 | 1.4.2.12.1 | **Verticales** | 5d | 2011-08-19 | 2011-08-25 |  | 102d |  |
| 197 | 1.4.2.12.1.1 | Acero | 4d | 2011-08-19 | 2011-08-24 | 187 | 102d | 0d |
| 198 | 1.4.2.12.1.2 | Encofrado | 4d | 2011-08-22 | 2011-08-25 | 197SS+1d | 141d | 0d |
| 199 | 1.4.2.12.1.3 | Concreto | 4d | 2011-08-22 | 2011-08-25 | 198SS | 141d | 0d |
| 200 | 1.4.2.12.2 | **Horizontales** | 5d | 2011-08-23 | 2011-08-29 |  | 141d |  |
| 201 | 1.4.2.12.2.1 | Encofrado de vigas | 4d | 2011-08-23 | 2011-08-26 | 199SS+1d | 141d | 0d |
| 202 | 1.4.2.12.2.2 | Encofrado de losas | 4d | 2011-08-23 | 2011-08-26 | 201SS | 141d | 0d |
| 203 | 1.4.2.12.2.3 | Acero de vigas y losas | 4d | 2011-08-24 | 2011-08-29 | 202SS+1d | 141d | 0d |
| 204 | 1.4.2.12.2.4 | Concreto | 4d | 2011-08-24 | 2011-08-29 | 203SS | 141d |  |
| 205 | 1.4.2.13 | **Piso 13** | 7d | 2011-08-25 | 2011-09-02 |  | 102d | 0d |
| 206 | 1.4.2.13.1 | **Verticales** | 5d | 2011-08-25 | 2011-08-31 |  | 102d |  |
| 207 | 1.4.2.13.1.1 | Acero | 4d | 2011-08-25 | 2011-08-30 | 197 | 102d | 0d |
| 208 | 1.4.2.13.1.2 | Encofrado | 4d | 2011-08-26 | 2011-08-31 | 207SS+1d | 137d | 0d |
| 209 | 1.4.2.13.1.3 | Concreto | 4d | 2011-08-26 | 2011-08-31 | 208SS | 137d | 0d |

| ID | WBS | Task | Duration | Start | Finish | Predecessors | Total slack | Free slack |
| --- | --- | --- | --- | --- | --- | --- | --- | --- |
| 210 | 1.4.2.13.2 | **Horizontales** | 5d | 2011-08-29 | 2011-09-02 |  | 137d |  |
| 211 | 1.4.2.13.2.1 | Encofrado de vigas | 4d | 2011-08-29 | 2011-09-01 | 209SS+1d | 137d | 0d |
| 212 | 1.4.2.13.2.2 | Encofrado de losas | 4d | 2011-08-29 | 2011-09-01 | 211SS | 137d | 0d |
| 213 | 1.4.2.13.2.3 | Acero de vigas y losas | 4d | 2011-08-30 | 2011-09-02 | 212SS+1d | 137d | 0d |
| 214 | 1.4.2.13.2.4 | Concreto | 4d | 2011-08-30 | 2011-09-02 | 213SS | 137d |  |
| 215 | 1.4.2.14 | **Piso 14** | 7d | 2011-08-31 | 2011-09-08 |  | 102d | 0d |
| 216 | 1.4.2.14.1 | **Verticales** | 5d | 2011-08-31 | 2011-09-06 |  | 102d |  |
| 217 | 1.4.2.14.1.1 | Acero | 4d | 2011-08-31 | 2011-09-05 | 207 | 102d | 0d |
| 218 | 1.4.2.14.1.2 | Encofrado | 4d | 2011-09-01 | 2011-09-06 | 217SS+1d | 133d | 0d |
| 219 | 1.4.2.14.1.3 | Concreto | 4d | 2011-09-01 | 2011-09-06 | 218SS | 133d | 0d |
| 220 | 1.4.2.14.2 | **Horizontales** | 5d | 2011-09-02 | 2011-09-08 |  | 133d |  |
| 221 | 1.4.2.14.2.1 | Encofrado de vigas | 4d | 2011-09-02 | 2011-09-07 | 219SS+1d | 133d | 0d |
| 222 | 1.4.2.14.2.2 | Encofrado de losas | 4d | 2011-09-02 | 2011-09-07 | 221SS | 133d | 0d |
| 223 | 1.4.2.14.2.3 | Acero de vigas y losas | 4d | 2011-09-05 | 2011-09-08 | 222SS+1d | 133d | 0d |
| 224 | 1.4.2.14.2.4 | Concreto | 4d | 2011-09-05 | 2011-09-08 | 223SS | 133d |  |
| 225 | 1.4.2.15 | **Piso 15** | 7d | 2011-09-06 | 2011-09-14 |  | 102d | 0d |
| 226 | 1.4.2.15.1 | **Verticales** | 5d | 2011-09-06 | 2011-09-12 |  | 102d |  |
| 227 | 1.4.2.15.1.1 | Acero | 4d | 2011-09-06 | 2011-09-09 | 217 | 102d | 0d |
| 228 | 1.4.2.15.1.2 | Encofrado | 4d | 2011-09-07 | 2011-09-12 | 227SS+1d | 129d | 0d |
| 229 | 1.4.2.15.1.3 | Concreto | 4d | 2011-09-07 | 2011-09-12 | 228SS | 129d | 0d |
| 230 | 1.4.2.15.2 | **Horizontales** | 5d | 2011-09-08 | 2011-09-14 |  | 129d |  |
| 231 | 1.4.2.15.2.1 | Encofrado de vigas | 4d | 2011-09-08 | 2011-09-13 | 229SS+1d | 129d | 0d |
| 232 | 1.4.2.15.2.2 | Encofrado de losas | 4d | 2011-09-08 | 2011-09-13 | 231SS | 129d | 0d |
| 233 | 1.4.2.15.2.3 | Acero de vigas y losas | 4d | 2011-09-09 | 2011-09-14 | 232SS+1d | 129d | 0d |
| 234 | 1.4.2.15.2.4 | Concreto | 4d | 2011-09-09 | 2011-09-14 | 233SS | 129d |  |

| ID | WBS | Task | Duration | Start | Finish | Predecessors | Total slack | Free slack |
| --- | --- | --- | --- | --- | --- | --- | --- | --- |
| 235 | 1.4.2.16 | **Piso 16** | 7d | 2011-09-12 | 2011-09-20 |  | 102d | 0d |
| 236 | 1.4.2.16.1 | **Verticales** | 5d | 2011-09-12 | 2011-09-16 |  | 102d |  |
| 237 | 1.4.2.16.1.1 | Acero | 4d | 2011-09-12 | 2011-09-15 | 227 | 102d | 0d |
| 238 | 1.4.2.16.1.2 | Encofrado | 4d | 2011-09-13 | 2011-09-16 | 237SS+1d | 125d | 0d |
| 239 | 1.4.2.16.1.3 | Concreto | 4d | 2011-09-13 | 2011-09-16 | 238SS | 125d | 0d |
| 240 | 1.4.2.16.2 | **Horizontales** | 5d | 2011-09-14 | 2011-09-20 |  | 125d |  |
| 241 | 1.4.2.16.2.1 | Encofrado de vigas | 4d | 2011-09-14 | 2011-09-19 | 239SS+1d | 125d | 0d |
| 242 | 1.4.2.16.2.2 | Encofrado de losas | 4d | 2011-09-14 | 2011-09-19 | 241SS | 125d | 0d |
| 243 | 1.4.2.16.2.3 | Acero de vigas y losas | 4d | 2011-09-15 | 2011-09-20 | 242SS+1d | 125d | 0d |
| 244 | 1.4.2.16.2.4 | Concreto | 4d | 2011-09-15 | 2011-09-20 | 243SS | 125d |  |
| 245 | 1.4.2.17 | **Piso 17** | 7d | 2011-09-16 | 2011-09-26 |  | 102d | 0d |
| 246 | 1.4.2.17.1 | **Verticales** | 5d | 2011-09-16 | 2011-09-22 |  | 102d |  |
| 247 | 1.4.2.17.1.1 | Acero | 4d | 2011-09-16 | 2011-09-21 | 237 | 102d | 0d |
| 248 | 1.4.2.17.1.2 | Encofrado | 4d | 2011-09-19 | 2011-09-22 | 247SS+1d | 121d | 0d |
| 249 | 1.4.2.17.1.3 | Concreto | 4d | 2011-09-19 | 2011-09-22 | 248SS | 121d | 0d |
| 250 | 1.4.2.17.2 | **Horizontales** | 5d | 2011-09-20 | 2011-09-26 |  | 121d |  |
| 251 | 1.4.2.17.2.1 | Encofrado de vigas | 4d | 2011-09-20 | 2011-09-23 | 249SS+1d | 121d | 0d |
| 252 | 1.4.2.17.2.2 | Encofrado de losas | 4d | 2011-09-20 | 2011-09-23 | 251SS | 121d | 0d |
| 253 | 1.4.2.17.2.3 | Acero de vigas y losas | 4d | 2011-09-21 | 2011-09-26 | 252SS+1d | 121d | 0d |
| 254 | 1.4.2.17.2.4 | Concreto | 4d | 2011-09-21 | 2011-09-26 | 253SS | 121d |  |
| 255 | 1.4.2.18 | **Azotea** | 7d | 2011-09-22 | 2011-09-30 |  | 102d | 0d |
| 256 | 1.4.2.18.1 | **Verticales** | 5d | 2011-09-22 | 2011-09-28 |  | 102d |  |
| 257 | 1.4.2.18.1.1 | Acero | 4d | 2011-09-22 | 2011-09-27 | 247 | 102d | 0d |
| 258 | 1.4.2.18.1.2 | Encofrado | 4d | 2011-09-23 | 2011-09-28 | 257SS+1d | 102d | 0d |
| 259 | 1.4.2.18.1.3 | Concreto | 4d | 2011-09-23 | 2011-09-28 | 258SS | 102d | 0d |

| ID | WBS | Task | Duration | Start | Finish | Predecessors | Total slack | Free slack |
| --- | --- | --- | --- | --- | --- | --- | --- | --- |
| 260 | 1.4.2.18.2 | **Horizontales** | 5d | 2011-09-26 | 2011-09-30 |  | 102d |  |
| 261 | 1.4.2.18.2.1 | Encofrado de vigas | 4d | 2011-09-26 | 2011-09-29 | 259SS+1d | 102d | 0d |
| 262 | 1.4.2.18.2.2 | Encofrado de losas | 4d | 2011-09-26 | 2011-09-29 | 261SS | 102d | 0d |
| 263 | 1.4.2.18.2.3 | Acero de vigas y losas | 4d | 2011-09-27 | 2011-09-30 | 262SS+1d | 102d | 0d |
| 264 | 1.4.2.18.2.4 | Concreto | 4d | 2011-09-27 | 2011-09-30 | 263SS | 102d |  |
| 265 | 1.5 | **ARQUITECTURA** | 201d | 2011-06-24 | 2012-03-30 |  | 20d |  |
| 266 | 1.5.1 | **Albañileria y Enlucidos** | 119d | 2011-06-24 | 2011-12-07 |  | 27d |  |
| 267 | 1.5.1.1 | **Muros** | 111d | 2011-06-24 | 2011-11-25 |  | 27d |  |
| 268 | 1.5.1.1.1 | Sotano 4 | 20d | 2011-06-24 | 2011-07-21 | 74 | 193d | 0d |
| 269 | 1.5.1.1.2 | Sotano 3 | 20d | 2011-06-29 | 2011-07-26 | 85 | 190d | 0d |
| 270 | 1.5.1.1.3 | Sotano 2 | 20d | 2011-07-05 | 2011-08-01 | 95 | 20d | 0d |
| 271 | 1.5.1.1.4 | Sotano 1 | 20d | 2011-07-11 | 2011-08-05 | 105 | 182d | 0d |
| 272 | 1.5.1.1.5 | Piso 1 | 25d | 2011-07-15 | 2011-08-18 | 115 | 173d | 0d |
| 273 | 1.5.1.1.6 | Piso 2 | 25d | 2011-07-21 | 2011-08-24 | 125 | 169d | 0d |
| 274 | 1.5.1.1.7 | Piso 3 | 25d | 2011-07-27 | 2011-08-30 | 135 | 165d | 0d |
| 275 | 1.5.1.1.8 | Piso 4 | 25d | 2011-08-02 | 2011-09-05 | 145 | 161d | 0d |
| 276 | 1.5.1.1.9 | Piso 5 | 25d | 2011-08-08 | 2011-09-09 | 155 | 157d | 0d |
| 277 | 1.5.1.1.10 | Piso 6 | 25d | 2011-08-12 | 2011-09-15 | 165 | 153d | 0d |
| 278 | 1.5.1.1.11 | Piso 7 | 25d | 2011-08-18 | 2011-09-21 | 175 | 149d | 0d |
| 279 | 1.5.1.1.12 | Piso 8 | 25d | 2011-08-24 | 2011-09-27 | 185 | 145d | 0d |
| 280 | 1.5.1.1.13 | Piso 9 | 25d | 2011-08-30 | 2011-10-03 | 195 | 141d | 0d |
| 281 | 1.5.1.1.14 | Piso 10 | 25d | 2011-09-05 | 2011-10-07 | 205 | 137d | 0d |
| 282 | 1.5.1.1.15 | Piso 11 | 25d | 2011-09-09 | 2011-10-13 | 215 | 133d | 0d |
| 283 | 1.5.1.1.16 | Piso 12 | 25d | 2011-09-15 | 2011-10-19 | 225 | 129d | 0d |
| 284 | 1.5.1.1.17 | Piso 13 | 25d | 2011-09-21 | 2011-10-25 | 235 | 125d | 0d |
| 285 | 1.5.1.1.18 | Piso 14 | 25d | 2011-09-27 | 2011-10-31 | 245 | 121d | 0d |
| 286 | 1.5.1.1.19 | Piso 15 | 25d | 2011-10-03 | 2011-11-04 | 255 | 102d | 0d |
| 287 | 1.5.1.1.20 | Piso 16 | 25d | 2011-10-11 | 2011-11-14 | 286SS+6d | 102d | 0d |
| 288 | 1.5.1.1.21 | Piso 17 | 25d | 2011-10-19 | 2011-11-22 | 287SS+6d | 102d | 0d |
| 289 | 1.5.1.1.22 | Azotea | 18d | 2011-11-02 | 2011-11-25 | 288SS+10d | 102d | 0d |

| ID | WBS | Task | Duration | Start | Finish | Predecessors | Total slack | Free slack |
| --- | --- | --- | --- | --- | --- | --- | --- | --- |
| 290 | 1.5.1.2 | **Tarrajeo** | 111d | 2011-06-29 | 2011-11-30 |  | 27d |  |
| 291 | 1.5.1.2.1 | Sotano 4 | 20d | 2011-06-29 | 2011-07-26 | 268SS+3d | 193d | 0d |
| 292 | 1.5.1.2.2 | Sotano 3 | 20d | 2011-07-04 | 2011-07-29 | 269SS+3d | 190d | 0d |
| 293 | 1.5.1.2.3 | Sotano 2 | 20d | 2011-07-08 | 2011-08-04 | 270SS+3d | 20d | 0d |
| 294 | 1.5.1.2.4 | Sotano 1 | 20d | 2011-07-14 | 2011-08-10 | 271SS+3d | 182d | 0d |
| 295 | 1.5.1.2.5 | Piso 1 | 25d | 2011-07-20 | 2011-08-23 | 272SS+3d | 173d | 0d |
| 296 | 1.5.1.2.6 | Piso 2 | 25d | 2011-07-26 | 2011-08-29 | 273SS+3d | 169d | 0d |
| 297 | 1.5.1.2.7 | Piso 3 | 25d | 2011-08-01 | 2011-09-02 | 274SS+3d | 165d | 0d |
| 298 | 1.5.1.2.8 | Piso 4 | 25d | 2011-08-05 | 2011-09-08 | 275SS+3d | 161d | 0d |
| 299 | 1.5.1.2.9 | Piso 5 | 25d | 2011-08-11 | 2011-09-14 | 276SS+3d | 157d | 0d |
| 300 | 1.5.1.2.10 | Piso 6 | 25d | 2011-08-17 | 2011-09-20 | 277SS+3d | 153d | 0d |
| 301 | 1.5.1.2.11 | Piso 7 | 25d | 2011-08-23 | 2011-09-26 | 278SS+3d | 149d | 0d |
| 302 | 1.5.1.2.12 | Piso 8 | 25d | 2011-08-29 | 2011-09-30 | 279SS+3d | 145d | 0d |
| 303 | 1.5.1.2.13 | Piso 9 | 25d | 2011-09-02 | 2011-10-06 | 280SS+3d | 141d | 0d |
| 304 | 1.5.1.2.14 | Piso 10 | 25d | 2011-09-08 | 2011-10-12 | 281SS+3d | 137d | 0d |
| 305 | 1.5.1.2.15 | Piso 11 | 25d | 2011-09-14 | 2011-10-18 | 282SS+3d | 133d | 0d |
| 306 | 1.5.1.2.16 | Piso 12 | 25d | 2011-09-20 | 2011-10-24 | 283SS+3d | 129d | 0d |
| 307 | 1.5.1.2.17 | Piso 13 | 25d | 2011-09-26 | 2011-10-28 | 284SS+3d | 125d | 0d |
| 308 | 1.5.1.2.18 | Piso 14 | 25d | 2011-09-30 | 2011-11-03 | 285SS+3d | 121d | 0d |
| 309 | 1.5.1.2.19 | Piso 15 | 25d | 2011-10-06 | 2011-11-09 | 286SS+3d | 117d | 0d |
| 310 | 1.5.1.2.20 | Piso 16 | 25d | 2011-10-14 | 2011-11-17 | 287SS+3d | 111d | 0d |
| 311 | 1.5.1.2.21 | Piso 17 | 25d | 2011-10-24 | 2011-11-25 | 288SS+3d | 105d | 0d |
| 312 | 1.5.1.2.22 | Azotea | 18d | 2011-11-07 | 2011-11-30 | 289SS+3d | 102d | 0d |
| 313 | 1.5.1.3 | **Contrapiso** | 111d | 2011-07-06 | 2011-12-07 |  | 27d |  |
| 314 | 1.5.1.3.1 | Sotano 4 | 20d | 2011-07-06 | 2011-08-02 | 291SS+5d | 193d |  |
| 315 | 1.5.1.3.2 | Sotano 3 | 20d | 2011-07-11 | 2011-08-05 | 292SS+5d | 190d |  |
| 316 | 1.5.1.3.3 | Sotano 2 | 20d | 2011-07-15 | 2011-08-11 | 293SS+5d | 20d | 0d |
| 317 | 1.5.1.3.4 | Sotano 1 | 20d | 2011-07-21 | 2011-08-17 | 294SS+5d | 182d |  |
| 318 | 1.5.1.3.5 | Piso 1 | 25d | 2011-07-27 | 2011-08-30 | 295SS+5d | 173d |  |
| 319 | 1.5.1.3.6 | Piso 2 | 25d | 2011-08-02 | 2011-09-05 | 296SS+5d | 169d |  |
| 320 | 1.5.1.3.7 | Piso 3 | 25d | 2011-08-08 | 2011-09-09 | 297SS+5d | 165d |  |
| 321 | 1.5.1.3.8 | Piso 4 | 25d | 2011-08-12 | 2011-09-15 | 298SS+5d | 161d |  |
| 322 | 1.5.1.3.9 | Piso 5 | 25d | 2011-08-18 | 2011-09-21 | 299SS+5d | 157d |  |
| 323 | 1.5.1.3.10 | Piso 6 | 25d | 2011-08-24 | 2011-09-27 | 300SS+5d | 153d |  |
| 324 | 1.5.1.3.11 | Piso 7 | 25d | 2011-08-30 | 2011-10-03 | 301SS+5d | 149d |  |
| 325 | 1.5.1.3.12 | Piso 8 | 25d | 2011-09-05 | 2011-10-07 | 302SS+5d | 145d |  |
| 326 | 1.5.1.3.13 | Piso 9 | 25d | 2011-09-09 | 2011-10-13 | 303SS+5d | 141d |  |
| 327 | 1.5.1.3.14 | Piso 10 | 25d | 2011-09-15 | 2011-10-19 | 304SS+5d | 137d |  |
| 328 | 1.5.1.3.15 | Piso 11 | 25d | 2011-09-21 | 2011-10-25 | 305SS+5d | 133d |  |
| 329 | 1.5.1.3.16 | Piso 12 | 25d | 2011-09-27 | 2011-10-31 | 306SS+5d | 129d |  |
| 330 | 1.5.1.3.17 | Piso 13 | 25d | 2011-10-03 | 2011-11-04 | 307SS+5d | 125d |  |
| 331 | 1.5.1.3.18 | Piso 14 | 25d | 2011-10-07 | 2011-11-10 | 308SS+5d | 121d |  |
| 332 | 1.5.1.3.19 | Piso 15 | 25d | 2011-10-13 | 2011-11-16 | 309SS+5d | 117d |  |
| 333 | 1.5.1.3.20 | Piso 16 | 25d | 2011-10-21 | 2011-11-24 | 310SS+5d | 111d |  |
| 334 | 1.5.1.3.21 | Piso 17 | 25d | 2011-10-31 | 2011-12-02 | 311SS+5d | 105d |  |
| 335 | 1.5.1.3.22 | Azotea | 18d | 2011-11-14 | 2011-12-07 | 312SS+5d | 102d |  |

| ID | WBS | Task | Type | Duration | Start | Finish | Predecessors | Total slack | Free slack |
| --- | --- | --- | --- | --- | --- | --- | --- | --- | --- |
| 336 | 1.5.2 | **Acabados** |  | 166d | 2011-08-12 | 2012-03-30 |  | 20d |  |
| 337 | 1.5.2.1 | Sotanos |  | 72d | 2011-08-12 | 2011-11-21 | 316 | 20d | 0d |
| 338 | 1.5.2.2 | Torre |  | 141d | 2011-09-16 | 2012-03-30 | 337SS+25d | 20d |  |
| 339 | 1.6 | **INSTALACIONES** |  | 245d | 2011-05-23 | 2012-04-27 |  | 0d |  |
| 340 | 1.6.1 | IIEE |  | 245d | 2011-05-23 | 2012-04-27 | 44SS | 0d |  |
| 341 | 1.6.2 | IISS |  | 245d | 2011-05-23 | 2012-04-27 | 44SS | 0d |  |
| 342 | 1.7 | Fin | milestone | 0d | 2012-04-27 | 2012-04-27 | 6, 37, 265, 339 | 0d |  |
